# PLAN DE GESTION DE INTEGRIDAD LINEA DE GAS

Schedule from MS Project, 2021-06-01 to 2023-01-23, status date 2021-10-26, 9 hours a day, costs in $.
PROYECTO UNIPILOTO

## Calendars

- PROYECTO UNIPILOTO: Mon-Fri 07:00-12:00, 13:00-17:00; Sat-Sun off. Exceptions (off unless hours are given): 2021-06-07 (DIA FESTIVO), 2021-06-14 (DIA FESTIVO), 2021-07-05 (DIA FESTIVO), 2021-07-20 (DIA FESTIVO), 2021-08-16 (DIA FESTIVO), 2021-10-18 (DIA FESTIVO), 2021-11-01 (DIA FESTIVO), 2021-11-15 (DIA FESTIVO), 2021-12-08 (DIA FESTIVO), 2021-12-25 (DIA FESTIVO), 2022-01-01 (DIA FESTIVO), 2022-01-10 (DIA FESTIVO), 2022-03-21 (DIA FESTIVO), 2022-04-14 (DIA FESTIVO), 2022-05-30 (DIA FESTIVO), 2022-06-20 (DIA FESTIVO), 2022-06-27 (DIA FESTIVO), 2022-07-04 (DIA FESTIVO), 2022-07-20 (DIA FESTIVO), 2022-08-15 (DIA FESTIVO), 2022-10-17 (DIA FESTIVO), 2022-11-07 (DIA FESTIVO), 2022-11-14 (DIA FESTIVO), 2022-12-08 (DIA FESTIVO).

## Resources

| Resource | Group | Rate |
| --- | --- | --- |
| DIRECTOR AMBIENTAL | HUMANO | 39027 |
| DIRECTOR ADMINISTRATIVO | HUMANO | 48029.7 |
| DIRECTOR DE MANTENIMIENTO | HUMANO | 42000 |
| DIRECTOR DE INTEGRIDAD | HUMANO | 42090.1 |
| PROFESIONAL QHSE | HUMANO | 35000 |
| DIRECTOR DE PROYECTOS | HUMANO | 82000 |
| GERENTE DE PROYECTOS | HUMANO | 90000 |
| DIRECTOR DE OBRA | HUMANO | 55753 |
| PROFESIONAL CIVIL | HUMANO | 45000 |
| RESIDENTE DE OBRA | HUMANO | 35000 |
| INSPECTOR HSE | HUMANO | 30000 |
| AUXILIAR HSE | HUMANO | 17000 |
| ESPECIALISTA EN PROCESOS DE CALIDAD | HUMANO | 50000 |
| INSPECTOR DE CALIDAD | HUMANO | 35000 |
| INGENIERO DE OPERACIONES | HUMANO | 45000 |
| PROFESIONAL MECANICO | HUMANO | 45000 |
| INGENIERO AMBIENTAL | HUMANO | 40000 |
| AUXILIAR AMBIENTAL | HUMANO | 20000 |
| RESIDENTE AMBIENTAL | HUMANO | 30000.1 |
| AUXILIAR AMBIENTAL 2 | HUMANO | 20000 |
| RESIDENTE ADMINISTRATIVO | HUMANO | 22301 |
| AUX ADMINISTRATIVA | HUMANO | 14336.9 |
| PROFESIONAL DE COMPRAS | HUMANO | 27728.8 |
| ALMACENISTA | HUMANO | 14337 |
| RESIDENTE RECURSOS HUMANOS | HUMANO | 23337 |
| PROFESIONAL DE MANTENIMIENTO MECANICO | HUMANO | 42547.7 |
| PROFESIONAL DE INTEGRIDAD | HUMANO | 39027 |
| CUADRILLA DE SUPERVISION LINEA | HUMANO | 70858.4 |
| SUB CONTRATO 3 - CUADRILLA DE MANTENIMEINTO | HUMANO | 315000 |
| EQUIPO DE COMPUTO |  | 2500 |
| PROFESIONAL SOCIAL |  | 25208 |
| AUXILIAR SOCIAL |  | 20000.4 |
| EQUIPO DE COMPUTO 2 |  | 2500 |
| EQUIPO DE COMPUTO 10 |  | 2500 |
| EQUIPO DE COMPUTO 3 |  | 2500 |
| EQUIPO DE COMPUTO 4 |  | 2500 |
| EQUIPO DE COMPUTO 5 |  | 2500 |
| EQUIPO DE COMPUTO 6 |  | 2500 |
| EQUIPO DE COMPUTO 7 |  | 2500 |
| EQUIPO DE COMPUTO 8 |  | 2500 |
| EQUIPO DE COMPUTO 9 |  | 2500 |
| CAMIONETA 1 |  | 17000 |
| CAMIONETA 2 |  | 17000 |
| CAMIONETA 3 |  | 17000 |
| SUBCONTRATO 1 - LEVANTAMIENTOS LINEAS OPERACIÓN |  | 166666 |
| SUBCONTRATO 2 - ESTUDIOS GEOTECNICOS |  | 180080 |
| AJUSTE 3,2 |  | 755 |
| AJUSTE 3,2.1 |  | 1232 |
| MATERIALES LINEA 13 |  | 1415816 |
| MATERIALES PERMISOS CAR |  | 9627354 |
| MATERIALES PERMISOS LOCAL |  | 6790990 |
| INFORME FINANCIERO |  | 65948 |
| INFORME SOCIAL |  | 36351 |
| ESTADOS FINANCIEROS |  | 171171 |
| VERIFICACION LINEA |  | 874883 |
| MATERIALES MANTENIMIENTO |  | 9232811 |
| MATERIALES SIMULACRO |  | 3548840 |
| MATERIALES INFORME FINAL |  | 3366 |
| RESERVA DE CONTINGENCIA |  | 154122293 |
| RESERVA DE GESTION |  | 161828408 |

## Schedule

| ID | WBS | Task | Type | Duration | Start | Finish | Predecessors | Baseline start | Baseline finish | Baseline duration | Baseline 1 start | Baseline 1 finish | Total slack | Free slack | Deadline | Resources | Work | Cost | Baseline cost |
| --- | --- | --- | --- | --- | --- | --- | --- | --- | --- | --- | --- | --- | --- | --- | --- | --- | --- | --- | --- |
| 1 | 1 | **GESTION ADMINISTRATIVA** |  | 102d | 2021-06-01 | 2021-10-28 |  | 2021-06-01 | 2021-10-28 | 102d | 2021-06-01 | 2021-10-28 | 0d |  | 2022-12-09 |  | 2754h | 154,671,402.6 | 140,610,366 |
| 2 | 1.1 | INICIO | milestone | 0d | 2021-06-01 | 2021-06-01 |  | 2021-06-01 | 2021-06-01 | 0d | 2021-06-01 | 2021-06-01 | 0d |  |  |  |  |  |  |
| 3 | 1.2 | CONTRATAR PERSONAL ADMINISTRATIVO |  | 34d | 2021-06-01 | 2021-07-22 | 2 | 2021-06-01 | 2021-07-22 | 34d | 2021-06-01 | 2021-07-22 | 0d |  | 2022-12-09 | RESIDENTE RECURSOS HUMANOS; AUX ADMINISTRATIVA | 612h | 11,528,213.4 | 10,480,194 |
| 4 | 1.3 | REALIZAR MATRIZ DE ROLES Y RESPONSABILIDADES |  | 34d | 2021-07-23 | 2021-09-09 | 3 | 2021-07-23 | 2021-09-09 | 34d | 2021-07-23 | 2021-09-09 | 10d | 0d | 2022-12-09 | DIRECTOR ADMINISTRATIVO; DIRECTOR DE PROYECTOS; GERENTE DE PROYECTOS | 918h | 67,329,088.2 | 61,208,262 |
| 5 | 1.4 | ELABORAR PLAN DE GESTION DE COMPRAS |  | 34d | 2021-09-10 | 2021-10-28 | 4 | 2021-09-10 | 2021-10-28 | 34d | 2021-09-10 | 2021-10-28 | 10d | 0d | 2022-12-09 | DIRECTOR ADMINISTRATIVO; DIRECTOR DE PROYECTOS; GERENTE DE PROYECTOS; PROFESIONAL DE COMPRAS | 1224h | 75,814,101 | 68,921,910 |
| 6 | 2 | **FACTIBILIDAD** |  | 101d | 2021-07-23 | 2021-12-17 |  | 2021-07-23 | 2021-12-17 | 101d | 2021-07-23 | 2021-12-17 | 0d |  | 2022-12-09 |  | 12402h | 643,334,384.21 | 584,849,438 |
| 7 | 2.1 | **EJECUTAR ESTUDIOS PREVIOS** |  | 101d | 2021-07-23 | 2021-12-17 |  | 2021-07-23 | 2021-12-17 | 101d | 2021-07-23 | 2021-12-17 | 0d |  | 2022-12-09 |  | 12402h | 643,334,384.21 | 584,849,438 |
| 8 | 2.1.1 | LEVANTAR LINEA DE OPERACION |  | 101d | 2021-07-23 | 2021-12-17 | 3 | 2021-07-23 | 2021-12-17 | 101d | 2021-07-23 | 2021-12-17 | 0d |  | 2022-12-09 | AUXILIAR AMBIENTAL 2 [50%]; AUXILIAR HSE [50%]; CUADRILLA DE SUPERVISION LINEA; DIRECTOR DE OBRA [50%]; INSPECTOR DE CALIDAD [50%]; INSPECTOR HSE [50%]; PROFESIONAL DE MANTENIMIENTO MECANICO; RESIDENTE AMBIENTAL [50%]; RESIDENTE DE OBRA [50%]; PROFESIONAL CIVIL; RESIDENTE RECURSOS HUMANOS [50%]; AUX ADMINISTRATIVA [50%]; CAMIONETA 1; CAMIONETA 2; CAMIONETA 3; EQUIPO DE COMPUTO; EQUIPO DE COMPUTO 2; EQUIPO DE COMPUTO 3; EQUIPO DE COMPUTO 4; EQUIPO DE COMPUTO 5; EQUIPO DE COMPUTO 6; EQUIPO DE COMPUTO 7; EQUIPO DE COMPUTO 8; AUXILIAR SOCIAL [50%]; SUBCONTRATO 1 - LEVANTAMIENTOS LINEAS OPERACIÓN | 8181h | 423,015,783.11 | 384,559,800.5 |
| 9 | 2.1.2 | REALIZAR ESTUDIOS GEOTECNICOS |  | 67d | 2021-07-23 | 2021-10-27 | 3 | 2021-07-23 | 2021-10-27 | 67d | 2021-07-23 | 2021-10-27 | 11d | 0d | 2022-12-09 | AUXILIAR AMBIENTAL 2 [50%]; AUXILIAR HSE [50%]; DIRECTOR DE OBRA [50%]; INGENIERO DE OPERACIONES; INSPECTOR DE CALIDAD [50%]; INSPECTOR HSE [50%]; RESIDENTE AMBIENTAL [50%]; RESIDENTE DE OBRA [50%]; RESIDENTE RECURSOS HUMANOS [50%]; AUX ADMINISTRATIVA [50%]; AUXILIAR SOCIAL [50%]; CAMIONETA 1; CAMIONETA 2; EQUIPO DE COMPUTO 6; EQUIPO DE COMPUTO 7; EQUIPO DE COMPUTO 8; EQUIPO DE COMPUTO 9; EQUIPO DE COMPUTO 10; SUBCONTRATO 2 - ESTUDIOS GEOTECNICOS | 4221h | 220,318,601.1 | 200,289,637.5 |
| 10 | 3 | **GESTION DE CALIDAD Y SEGURIDAD** |  | 67d | 2021-10-28 | 2022-02-03 |  | 2021-10-28 | 2022-02-03 | 67d | 2021-10-28 | 2022-02-03 | 11d |  | 2022-12-09 |  | 5851.35h | 269,388,096.66 | 244,898,269.1 |
| 11 | 3.1 | ELABORAR PLAN DE GESTION DE CALIDAD |  | 67d | 2021-10-28 | 2022-02-03 | 9 | 2021-10-28 | 2022-02-03 | 67d | 2021-10-28 | 2022-02-03 | 191d |  | 2022-12-09 | DIRECTOR DE PROYECTOS [45%]; ESPECIALISTA EN PROCESOS DE CALIDAD [45%]; GERENTE DE PROYECTOS [45%]; INSPECTOR DE CALIDAD [95%]; PROFESIONAL DE INTEGRIDAD [50%]; PROFESIONAL DE MANTENIMIENTO MECANICO [50%]; PROFESIONAL MECANICO [50%]; PROFESIONAL QHSE [45%]; DIRECTOR AMBIENTAL [40%]; DIRECTOR DE INTEGRIDAD [40%]; DIRECTOR DE MANTENIMIENTO [40%]; CAMIONETA 3; EQUIPO DE COMPUTO; EQUIPO DE COMPUTO 2 | 3286.35h | 157,666,818.98 | 143,333,471.35 |
| 12 | 3.2 | ELABORAR PROTOCOLOS DE MANTENIMEINTO |  | 45d | 2021-10-29 | 2022-01-04 | 9, 5 | 2021-10-29 | 2022-01-04 | 45d | 2021-10-29 | 2022-01-04 | 10d |  | 2022-12-09 | DIRECTOR DE PROYECTOS [45%]; ESPECIALISTA EN PROCESOS DE CALIDAD [45%]; GERENTE DE PROYECTOS [45%]; PROFESIONAL DE INTEGRIDAD [30%]; PROFESIONAL DE MANTENIMIENTO MECANICO [50%]; PROFESIONAL MECANICO [50%]; DIRECTOR AMBIENTAL [40%]; DIRECTOR DE INTEGRIDAD [30%]; DIRECTOR DE MANTENIMIENTO [40%]; PROFESIONAL QHSE [45%]; CAMIONETA 2; CAMIONETA 3; EQUIPO DE COMPUTO 3; EQUIPO DE COMPUTO 4; EQUIPO DE COMPUTO 5; AJUSTE 3,2; AJUSTE 3,2.1 | 2106h | 87,897,269.11 | 79,906,608.25 |
| 13 | 3.3 | ELABORAR PORTOCOLOS DE ATENCION DE EMERGENCIA |  | 17d | 2021-10-28 | 2021-11-23 | 9 | 2021-10-28 | 2021-11-23 | 17d | 2021-10-28 | 2021-11-23 | 39d |  | 2022-12-09 | DIRECTOR AMBIENTAL [20%]; DIRECTOR DE INTEGRIDAD [20%]; DIRECTOR DE MANTENIMIENTO [20%]; DIRECTOR DE OBRA; DIRECTOR DE PROYECTOS [10%]; ESPECIALISTA EN PROCESOS DE CALIDAD [10%]; GERENTE DE PROYECTOS [10%]; INGENIERO AMBIENTAL; PROFESIONAL QHSE [10%]; CAMIONETA 1; CAMIONETA 2; CAMIONETA 3; EQUIPO DE COMPUTO 6; EQUIPO DE COMPUTO 7; EQUIPO DE COMPUTO 8; MATERIALES LINEA 13 | 459h | 23,824,008.57 | 21,658,189.5 |
| 14 | 4 | **GESTION AMBIENTAL** |  | 101d | 2021-12-20 | 2022-05-12 |  | 2021-12-20 | 2022-05-12 | 101d | 2021-12-20 | 2022-05-12 | 140d |  | 2022-12-09 |  | 6532.2h | 405,694,168 | 368,812,878.6 |
| 15 | 4.1 | GESTIONAR PERMISOS ANTE LA CAR |  | 101d | 2021-12-20 | 2022-05-12 | 9, 8 | 2021-12-20 | 2022-05-12 | 101d | 2021-12-20 | 2022-05-12 | 140d |  | 2022-12-09 | AUXILIAR AMBIENTAL [40%]; DIRECTOR AMBIENTAL; INGENIERO AMBIENTAL; DIRECTOR DE PROYECTOS; GERENTE DE PROYECTOS; CAMIONETA 3; EQUIPO DE COMPUTO 9; MATERIALES PERMISOS CAR | 3999.6h | 245,102,397 | 222,820,360.8 |
| 16 | 4.2 | GESTIONAR PERMISOS ANTE LA ANLA |  | 67d | 2021-12-20 | 2022-03-24 | 9, 8 | 2021-12-20 | 2022-03-24 | 67d | 2021-12-20 | 2022-03-24 | 174d |  | 2022-12-09 | AUXILIAR AMBIENTAL [20%]; DIRECTOR DE PROYECTOS; GERENTE DE PROYECTOS; INGENIERO AMBIENTAL; DIRECTOR AMBIENTAL; CAMIONETA 1; EQUIPO DE COMPUTO 10; MATERIALES PERMISOS LOCAL | 2532.6h | 160,591,771 | 145,992,517.8 |
| 17 | 5 | **LINEA BASE** |  | 56d | 2021-10-28 | 2022-01-19 |  | 2021-10-28 | 2022-01-19 | 56d | 2021-10-28 | 2022-01-19 | 32d |  | 2022-12-09 |  | 203.4h | 8,604,711.94 | 7,822,465.8 |
| 18 | 5.1 | REALIZAR INFORME DE ESTADOS FINANCIEROS |  | 2d | 2021-10-28 | 2021-10-29 | 9 | 2021-10-28 | 2021-10-29 | 2d | 2021-10-28 | 2021-10-29 | 32d |  | 2022-12-09 | ALMACENISTA; DIRECTOR ADMINISTRATIVO; DIRECTOR DE PROYECTOS; GERENTE DE PROYECTOS; PROFESIONAL DE COMPRAS; RESIDENTE ADMINISTRATIVO; INFORME FINANCIERO | 108h | 5,185,085 | 4,713,714 |
| 19 | 5.2 | REALIZAR INFORME DE IMPACTO SOCIAL |  | 2d | 2021-10-28 | 2021-10-29 | 9 | 2021-10-28 | 2021-10-29 | 2d | 2021-10-28 | 2021-10-29 | 256d |  | 2022-12-09 | AUXILIAR SOCIAL; PROFESIONAL SOCIAL; CAMIONETA 1; EQUIPO DE COMPUTO; INFORME SOCIAL | 36h | 869,602.56 | 790,548 |
| 20 | 5.3 | REALIZAR EVALUACION DE ESTADO DE ACTIVOS |  | 22d | 2021-12-20 | 2022-01-19 | 18, 8, 9 | 2021-12-20 | 2022-01-19 | 22d | 2021-12-20 | 2022-01-19 | 0d |  | 2022-12-09 | DIRECTOR DE INTEGRIDAD [10%]; PROFESIONAL DE INTEGRIDAD [20%]; ESTADOS FINANCIEROS | 59.4h | 2,550,024.38 | 2,318,203.8 |
| 21 | 6 | **OPERACION** |  | 220d | 2022-01-20 | 2022-12-09 |  | 2022-01-20 | 2022-12-09 | 220d | 2022-01-20 | 2022-12-09 | 0d |  | 2022-12-09 |  | 29935.3h | 1,600,753,108.89 | 1,455,230,099.2 |
| 22 | 6.1 | VERIFICAR LINEAS DE TRANSPORTE |  | 202d | 2022-01-20 | 2022-11-11 | 20, 13 | 2022-01-20 | 2022-11-11 | 202d | 2022-01-20 | 2022-11-11 | 0d |  | 2022-12-09 | AUXILIAR HSE [50%]; INSPECTOR DE CALIDAD [45%]; INSPECTOR HSE [50%]; RESIDENTE DE OBRA [50%]; CAMIONETA 1; CAMIONETA 2; CAMIONETA 3; EQUIPO DE COMPUTO 3; EQUIPO DE COMPUTO 4; EQUIPO DE COMPUTO 5; EQUIPO DE COMPUTO 6; EQUIPO DE COMPUTO 7; EQUIPO DE COMPUTO 8; EQUIPO DE COMPUTO 9; EQUIPO DE COMPUTO 10; AUXILIAR AMBIENTAL [40%]; PROFESIONAL DE MANTENIMIENTO MECANICO [50%]; CUADRILLA DE SUPERVISION LINEA [73%]; VERIFICACION LINEA | 6508.44h | 251,376,246 | 228,523,860.2 |
| 23 | 6.2 | EJECUTAR MANTENIMEINTOS |  | 202d | 2022-01-20 | 2022-11-11 | 20, 12 | 2022-01-20 | 2022-11-11 | 202d | 2022-01-20 | 2022-11-11 | 0d |  | 2022-12-09 | AUXILIAR AMBIENTAL 2; AUXILIAR HSE [50%]; DIRECTOR DE MANTENIMIENTO; INGENIERO DE OPERACIONES; INSPECTOR DE CALIDAD [50%]; INSPECTOR HSE [50%]; PROFESIONAL DE MANTENIMIENTO MECANICO [50%]; PROFESIONAL MECANICO; RESIDENTE AMBIENTAL; RESIDENTE DE OBRA [50%]; CAMIONETA 1; CAMIONETA 2; CAMIONETA 3; EQUIPO DE COMPUTO; EQUIPO DE COMPUTO 2; EQUIPO DE COMPUTO 3; EQUIPO DE COMPUTO 4; EQUIPO DE COMPUTO 5; EQUIPO DE COMPUTO 6; EQUIPO DE COMPUTO 7; EQUIPO DE COMPUTO 8; ALMACENISTA; AUXILIAR SOCIAL; SUB CONTRATO 3 - CUADRILLA DE MANTENIMEINTO; ESPECIALISTA EN PROCESOS DE CALIDAD; EQUIPO DE COMPUTO 10; MATERIALES MANTENIMIENTO | 20907h | 1,211,206,745.3 | 1,101,097,041 |
| 24 | 6.3 | REALIZAR SIMULACRO DE ATENCION DE EMERGENCIA |  | 17d | 2022-11-15 | 2022-12-07 | 22, 23, 11, 19 | 2022-11-15 | 2022-12-07 | 17d | 2022-11-15 | 2022-12-07 | 0d |  | 2022-12-09 | AUXILIAR AMBIENTAL; AUXILIAR AMBIENTAL 2; AUXILIAR HSE; AUXILIAR SOCIAL; DIRECTOR DE MANTENIMIENTO; DIRECTOR DE PROYECTOS; INGENIERO DE OPERACIONES; PROFESIONAL DE MANTENIMIENTO MECANICO; PROFESIONAL QHSE; PROFESIONAL SOCIAL; RESIDENTE AMBIENTAL; CAMIONETA 1; CAMIONETA 2; CAMIONETA 3; EQUIPO DE COMPUTO 9; EQUIPO DE COMPUTO 10; SUB CONTRATO 3 - CUADRILLA DE MANTENIMEINTO; DIRECTOR DE OBRA; INGENIERO AMBIENTAL; INSPECTOR HSE; RESIDENTE DE OBRA; MATERIALES SIMULACRO | 2448h | 134,344,747.6 | 122,131,589 |
| 25 | 6.4 | ENTEGAR EL PLAN DE GESTION |  | 1d | 2022-12-09 | 2022-12-09 | 24, 22, 23, 15, 16 | 2022-12-09 | 2022-12-09 | 1d | 2022-12-09 | 2022-12-09 | 0d |  | 2022-12-09 | DIRECTOR DE INTEGRIDAD; DIRECTOR DE PROYECTOS; ESPECIALISTA EN PROCESOS DE CALIDAD; GERENTE DE PROYECTOS; INSPECTOR DE CALIDAD; PROFESIONAL DE INTEGRIDAD; DIRECTOR DE MANTENIMIENTO; PROFESIONAL MECANICO [99%]; MATERIALES INFORME FINAL | 71.91h | 3,825,369.99 | 3,477,609 |
| 26 | 6.5 | Fin | milestone | 0d | 2022-12-09 | 2022-12-09 | 25 | 2022-12-09 | 2022-12-09 | 0d | 2022-12-09 | 2022-12-09 | 0d |  |  |  |  |  |  |
| 27 | 7 | RESERVA DE CONTINGENCIA |  | 31d | 2022-12-12 | 2023-01-23 | 26 |  |  |  |  |  | 0d |  |  | RESERVA DE CONTINGENCIA |  | 154,122,293 |  |
